# Human Resource Information System Implementation

Schedule from MS Project, 2007-04-02 to 2007-07-02.
This template outlines the steps, from an HR perspective and at a very high level, needed to implement an HRIS. It is not specific to any commercial software system.

## Calendars

- Standard: Mon-Fri 08:00-12:00, 13:00-17:00; Sat-Sun off.

## Resources

| Resource |
| --- |
| Executive Management |
| Information Systems |
| Human Resources |
| Procurement |

## Schedule

| ID | WBS | Task | Type | Duration | Start | Finish | Predecessors | Total slack | Free slack | Resources | Work |
| --- | --- | --- | --- | --- | --- | --- | --- | --- | --- | --- | --- |
| 1 | 1 | Business Case for HRIS Implementation Approved by Executive Management | milestone | 0d | 2007-04-02 | 2007-04-02 |  | 0d |  |  |  |
| 2 | 2 | **Analysis and Requirements** |  | 3d? | 2007-04-02 | 2007-04-04 |  | 0d |  |  | 40h |
| 3 | 2.1 | **HR Data Requirements** |  | 3d? | 2007-04-02 | 2007-04-04 |  | 0d |  |  | 24h |
| 4 | 2.1.1 | Review Existing Materials |  | 1d? | 2007-04-02 | 2007-04-02 | 1 | 0d |  | Human Resources | 8h |
| 5 | 2.1.2 | Conduct User Base Requirements Sessions |  | 1d? | 2007-04-03 | 2007-04-03 | 4 | 0d |  | Human Resources | 8h |
| 6 | 2.1.3 | Develop User Needs Assessment and Complete HR Business Process Flow |  | 1d? | 2007-04-04 | 2007-04-04 | 5 | 0d |  | Human Resources | 8h |
| 7 | 2.1.4 | HR Data Requirements Assessment Complete | milestone | 0d | 2007-04-04 | 2007-04-04 | 6 | 62.5d |  |  |  |
| 8 | 2.2 | **Technical Infrastructure Requirements** |  | 2d? | 2007-04-02 | 2007-04-03 |  | 1d |  |  | 16h |
| 9 | 2.2.1 | Review Current Infrastructure |  | 1d? | 2007-04-02 | 2007-04-02 | 1 | 1d | 0d | Information Systems | 8h |
| 10 | 2.2.2 | Project Future Demand |  | 1d? | 2007-04-03 | 2007-04-03 | 9 | 1d | 0d | Information Systems | 8h |
| 11 | 2.2.3 | Technical Infrastructure Requirements Assessment Complete | milestone | 0d | 2007-04-03 | 2007-04-03 | 10 | 63.5d |  |  |  |
| 12 | 2.3 | Analysis and Requirements Complete | milestone | 0d | 2007-04-04 | 2007-04-04 | 6, 10 | 0d |  |  |  |
| 13 | 3 | **Assessment of HRIS Solutions** |  | 7d? | 2007-04-05 | 2007-04-13 |  | 0d |  |  | 104h |
| 14 | 3.1 | Develop RFP |  | 1d? | 2007-04-05 | 2007-04-05 | 12 | 0d |  | Human Resources; Information Systems | 16h |
| 15 | 3.2 | Determine Weightings to be Given to Responses |  | 1d? | 2007-04-06 | 2007-04-06 | 14 | 0d |  | Human Resources; Information Systems | 16h |
| 16 | 3.3 | Issue RFP |  | 1d? | 2007-04-09 | 2007-04-09 | 15 | 0d |  | Procurement | 8h |
| 17 | 3.4 | Evaluate Responses |  | 1d? | 2007-04-10 | 2007-04-10 | 16 | 0d |  | Human Resources; Information Systems | 16h |
| 18 | 3.5 | Perform Vendor Response/Requirements Gap Analysis |  | 1d? | 2007-04-11 | 2007-04-11 | 17 | 0d |  | Human Resources; Information Systems | 16h |
| 19 | 3.6 | Invite Top Candidates to Demo |  | 1d? | 2007-04-12 | 2007-04-12 | 18 | 0d |  | Human Resources; Procurement | 16h |
| 20 | 3.7 | Select Best Fit HRIS Vendor Solution |  | 1d? | 2007-04-13 | 2007-04-13 | 19 | 0d |  | Human Resources; Information Systems | 16h |
| 21 | 3.8 | Assessment of HRIS Solutions Complete | milestone | 0d | 2007-04-13 | 2007-04-13 | 20 | 0d |  |  |  |
| 22 | 4 | Procure HRIS Solution |  | 1d? | 2007-04-16 | 2007-04-16 | 21 | 0d |  |  |  |
| 23 | 5 | **Design HRIS Solution** |  | 13d? | 2007-04-17 | 2007-05-03 |  | 0d |  |  | 208h |
| 24 | 5.1 | **Iteration Planning** |  | 3d | 2007-04-17 | 2007-04-19 |  | 0d |  |  | 32h |
| 25 | 5.1.1 | Conduct User and Team Training |  | 1d | 2007-04-17 | 2007-04-17 | 22 | 0d |  | Information Systems | 8h |
| 26 | 5.1.2 | Define Iterations |  | 1d | 2007-04-18 | 2007-04-18 | 25 | 0d |  | Information Systems | 8h |
| 27 | 5.1.3 | Define Test Approach |  | 1d | 2007-04-18 | 2007-04-18 | 25 | 0d |  | Information Systems | 8h |
| 28 | 5.1.4 | Review and Baseline Iteration Plan |  | 1d | 2007-04-19 | 2007-04-19 | 27, 26 | 0d |  | Information Systems | 8h |
| 29 | 5.1.5 | Iteration Planning Complete | milestone | 0d | 2007-04-19 | 2007-04-19 | 28 | 0d |  |  |  |

Notes:
- 4: Review prior work on HR business processes and requirements and technology initiatives currently underway.
- 5: Hold sessions with HR administrators. Purpose is to confirm existing HR data requirements, identify new requirements, understand current business processes, and identify problems and suggested strategies to meet gaps.
- 13: Preliminary assessment of HRIS solutions available on the market that meet the core functional requirements discovered earlier.

| ID | WBS | Task | Type | Duration | Start | Finish | Predecessors | Total slack | Free slack | Resources | Work |
| --- | --- | --- | --- | --- | --- | --- | --- | --- | --- | --- | --- |
| 30 | 5.2 | **Implementation Prototyping** |  | 4d | 2007-04-18 | 2007-04-23 |  | 47.5d |  |  | 48h |
| 31 | 5.2.1 | Develop Scenarios |  | 1d | 2007-04-18 | 2007-04-18 | 25 | 47.5d | 0d | Information Systems | 8h |
| 32 | 5.2.2 | Map Scenarios to Package Transactions |  | 1d | 2007-04-19 | 2007-04-19 | 31 | 51.5d |  | Information Systems | 8h |
| 33 | 5.2.3 | Define the Scenario Steps |  | 1d | 2007-04-19 | 2007-04-19 | 31 | 50.5d | 0d | Information Systems | 8h |
| 34 | 5.2.4 | Specify and Prototype Reports |  | 1d | 2007-04-20 | 2007-04-20 | 33 | 50.5d |  | Information Systems | 8h |
| 35 | 5.2.5 | Specify External Interfaces |  | 1d | 2007-04-19 | 2007-04-19 | 31 | 47.5d | 0d | Information Systems | 8h |
| 36 | 5.2.6 | Build Package Prototype |  | 1d | 2007-04-20 | 2007-04-20 | 35 | 47.5d | 0d | Information Systems | 8h |
| 37 | 5.2.7 | Exercise/Review Package Prototype |  | 1d | 2007-04-23 | 2007-04-23 | 36 | 47.5d | 0d |  |  |
| 38 | 5.2.8 | Implementation Prototyping Complete | milestone | 0d | 2007-04-23 | 2007-04-23 | 37 | 47.5d | 0d |  |  |
| 39 | 5.3 | **Iteration Consolidation** |  | 2d? | 2007-04-24 | 2007-04-25 |  | 47.5d |  |  | 16h |
| 40 | GRBAPI.PC.04.010 | Design Systems and Integration Test Cases |  | 1d? | 2007-04-24 | 2007-04-24 | 38 | 47.5d | 0d | Information Systems [50%]; Human Resources [50%] | 8h |
| 41 | GRBAPI.PC.04.020 | Confirm Scope of Future Iterations |  | 1d? | 2007-04-25 | 2007-04-25 | 40 | 47.5d | 0d | Information Systems [50%]; Human Resources [50%] | 8h |
| 42 | 5.3.3 | Iteration Consolidation Complete | milestone | 0d | 2007-04-25 | 2007-04-25 | 41 | 47.5d |  |  |  |
| 43 | 5.4 | **Data Migration Design** |  | 6d | 2007-04-20 | 2007-04-27 |  | 0d |  |  | 64h |
| 44 | GRBAPI.PC.05.010 | Review Data Acquisition Strategy |  | 1d | 2007-04-20 | 2007-04-20 | 29 | 0d |  | Information Systems | 8h |
| 45 | GRBAPI.PC.05.020 | Define Data Migration Sources |  | 1d | 2007-04-23 | 2007-04-23 | 44 | 0d |  | Information Systems | 8h |
| 46 | GRBAPI.PC.05.030 | Define Data Migration Rules and Logic |  | 1d | 2007-04-24 | 2007-04-24 | 45 | 0d |  | Information Systems | 8h |
| 47 | GRBAPI.PC.05.040 | Perform Data Cleanup |  | 1d | 2007-04-24 | 2007-04-24 | 45 | 48.5d |  | Information Systems | 8h |
| 48 | GRBAPI.PC.05.050 | Design Data Migration Transactions |  | 1d | 2007-04-25 | 2007-04-25 | 46, 45 | 47.5d |  | Information Systems | 8h |
| 49 | GRBAPI.PC.05.060 | Determine Data Migration Procedures and Controls |  | 1d | 2007-04-25 | 2007-04-25 | 46 | 0d |  | Information Systems | 8h |
| 50 | GRBAPI.PC.05.070 | Review and Baseline Conversion Design |  | 1d | 2007-04-26 | 2007-04-26 | 49 | 0d |  | Information Systems | 8h |
| 51 | GRBAPI.PC.05.080 | Obtain Signoff of Conversion Design |  | 1d | 2007-04-27 | 2007-04-27 | 50 | 0d |  | Information Systems [50%]; Human Resources [50%] | 8h |
| 52 | 5.4.9 | Data Migration Design Complete | milestone | 0d | 2007-04-27 | 2007-04-27 | 51 | 0d |  |  |  |
| 53 | 5.5 | **Finalize Integration Design Phase** |  | 4d | 2007-04-30 | 2007-05-03 |  | 0d |  |  | 48h |
| 54 | GRBAPI.PC.GRSEA.010 | Develop Requirements Traceability Matrix |  | 1d | 2007-04-30 | 2007-04-30 | 52 | 0d |  | Information Systems | 8h |
| 55 | GRBAPI.PC.GRSEA.020 | Baseline Project/Deliverables |  | 1d | 2007-05-01 | 2007-05-01 | 54 | 0d |  | Information Systems | 8h |
| 56 | GRBAPI.PC.GRSEA.030 | Develop Schedule for Next Stage |  | 1d | 2007-05-02 | 2007-05-02 | 55 | 0d |  | Information Systems [50%]; Human Resources [50%] | 8h |
| 57 | GRBAPI.PC.GRSEA.040 | Review Project Status with Project Board |  | 1d | 2007-05-03 | 2007-05-03 | 56 | 0d |  | Human Resources; Executive Management; Information Systems | 24h |
| 58 | 5.5.5 | Finalize Integration Design Phase Complete | milestone | 0d | 2007-05-03 | 2007-05-03 | 57 | 0d |  |  |  |
| 59 | 5.6 | Integration Design Complete | milestone | 0d | 2007-05-03 | 2007-05-03 | 58 | 0d |  |  |  |

| ID | WBS | Task | Type | Duration | Start | Finish | Predecessors | Total slack | Resources | Work |
| --- | --- | --- | --- | --- | --- | --- | --- | --- | --- | --- |
| 60 | 6 | **Integration, Build, Test** |  | 24.5d | 2007-05-04 | 2007-06-07 |  | 0d |  | 320h |
| 61 | 6.1 | **Build Iteration Planning** |  | 3d | 2007-05-04 | 2007-05-08 |  | 0d |  | 32h |
| 62 | GRBAPI.PINT.02.010 | Confirm Technical Architecture |  | 1d | 2007-05-04 | 2007-05-04 | 59 | 0d | Information Systems | 8h |
| 63 | GRBAPI.PINT.02.020 | Define Iterations and Builds |  | 1d | 2007-05-07 | 2007-05-07 | 62 | 0d | Information Systems | 8h |
| 64 | GRBAPI.PINT.02.030 | Refine Test Cases |  | 1d | 2007-05-08 | 2007-05-08 | 63 | 0d | Human Resources; Information Systems | 16h |
| 65 | 6.1.4 | Build Iteration Planning Complete | milestone | 0d | 2007-05-08 | 2007-05-08 | 64 | 0d |  |  |
| 66 | 6.2 | **Integration Build** |  | 4.5d | 2007-05-09 | 2007-05-15 |  | 0d |  | 56h |
| 67 | GRBAPI.PINT.03.010 | Build Reports |  | 1d | 2007-05-09 | 2007-05-09 | 65 | 0d | Information Systems | 8h |
| 68 | GRBAPI.PINT.03.020 | Design and Build Migration Components |  | 1d | 2007-05-10 | 2007-05-10 | 67 | 0d | Information Systems | 8h |
| 69 | GRBAPI.PINT.03.030 | Design and Build External Interfaces |  | 1d | 2007-05-11 | 2007-05-11 | 68 | 35.5d | Information Systems | 8h |
| 70 | GRBAPI.PINT.03.040 | Optimize Performance |  | 1d | 2007-05-11 | 2007-05-11 | 68 | 35.5d | Information Systems | 8h |
| 71 | GRBAPI.PINT.03.050 | Complete Unit/Integration Testing |  | 1d | 2007-05-10 | 2007-05-11 | 68SS+5% | 0d | Information Systems | 8h |
| 72 | GRBAPI.PINT.03.060 | Review and Baseline Build |  | 1d | 2007-05-11 | 2007-05-14 | 71 | 0d | Information Systems | 8h |
| 73 | GRBAPI.PINT.03.070 | Deliver Build for Testing |  | 1d | 2007-05-14 | 2007-05-15 | 72 | 0d | Information Systems | 8h |
| 74 | 6.2.8 | Integration Build Complete | milestone | 0d | 2007-05-15 | 2007-05-15 | 73 | 0d |  |  |
| 75 | 6.3 | **System Test Design and Development** |  | 2d | 2007-05-15 | 2007-05-17 |  | 0d |  | 32h |
| 76 | GRBAPI.PINT.04.010 | Define Test Scripts |  | 1d | 2007-05-15 | 2007-05-16 | 74 | 0d | Information Systems | 8h |
| 77 | GRBAPI.PINT.04.020 | Review Test Case/Requirement Coverage |  | 1d | 2007-05-16 | 2007-05-17 | 76 | 32d | Information Systems | 8h |
| 78 | GRBAPI.PINT.04.030 | Develop Automated Scripts |  | 1d | 2007-05-15 | 2007-05-16 | 76SS | 33d | Information Systems | 8h |
| 79 | GRBAPI.PINT.04.040 | Establish External Test Data Sets |  | 1d | 2007-05-16 | 2007-05-17 | 76 | 0d | Information Systems | 8h |
| 80 | 6.3.5 | System Test Design and Development Complete | milestone | 0d | 2007-05-17 | 2007-05-17 | 79 | 0d |  |  |
| 81 | 6.4 | **System Test Execution** |  | 3d | 2007-05-17 | 2007-05-22 |  | 0d |  | 24h |
| 82 | GRBAPI.PINT.05.010 | Execute Tests and Log Results |  | 1d | 2007-05-17 | 2007-05-18 | 80 | 0d | Information Systems | 8h |
| 83 | GRBAPI.PINT.05.020 | Investigate Unexpected Results |  | 1d | 2007-05-18 | 2007-05-21 | 82 | 0d | Information Systems | 8h |
| 84 | GRBAPI.PINT.05.030 | Estimate, Prioritize, and Schedule Testing Changes |  | 1d | 2007-05-21 | 2007-05-22 | 83 | 0d | Information Systems | 8h |
| 85 | 6.4.4 | System Test Execution Complete | milestone | 0d | 2007-05-22 | 2007-05-22 | 84 | 0d |  |  |

| ID | WBS | Task | Type | Duration | Start | Finish | Predecessors | Total slack | Resources | Work |
| --- | --- | --- | --- | --- | --- | --- | --- | --- | --- | --- |
| 86 | 6.5 | **Iteration Review** |  | 2d | 2007-05-22 | 2007-05-24 |  | 0d |  | 32h |
| 87 | GRBAPI.PINT.06.010 | Review System Test Results for Current Iteration |  | 1d | 2007-05-22 | 2007-05-23 | 85 | 0d | Information Systems; Human Resources | 16h |
| 88 | GRBAPI.PINT.06.020 | Confirm Scope of Future Iterations |  | 1d | 2007-05-23 | 2007-05-24 | 87 | 0d | Human Resources; Information Systems | 16h |
| 89 | 6.5.3 | Iteration Review Complete | milestone | 0d | 2007-05-24 | 2007-05-24 | 88 | 0d |  |  |
| 90 | 6.6 | **Acceptance Testing** |  | 6d | 2007-05-24 | 2007-06-01 |  | 0d |  | 88h |
| 91 | GRBAPI.PINT.07.010 | Set Up Acceptance Test Environment |  | 1d | 2007-05-24 | 2007-05-25 | 89 | 0d | Information Systems | 8h |
| 92 | GRBAPI.PINT.07.020 | Create Acceptance Test Scripts |  | 1d | 2007-05-25 | 2007-05-28 | 91 | 0d | Information Systems; Human Resources | 16h |
| 93 | GRBAPI.PINT.07.030 | Execute Acceptance Tests and Log Results |  | 1d | 2007-05-28 | 2007-05-29 | 92 | 0d | Information Systems; Human Resources | 16h |
| 94 | GRBAPI.PINT.07.040 | Update System Based on Acceptance Test Results |  | 1d | 2007-05-29 | 2007-05-30 | 93 | 0d | Information Systems; Human Resources | 16h |
| 95 | GRBAPI.PINT.07.050 | Re-Execute Acceptance Tests and Log Results |  | 1d | 2007-05-30 | 2007-05-31 | 94 | 0d | Information Systems; Human Resources | 16h |
| 96 | GRBAPI.PINT.07.060 | Obtain Signoff of System |  | 1d | 2007-05-31 | 2007-06-01 | 95 | 0d | Information Systems; Human Resources | 16h |
| 97 | 6.6.7 | Acceptance Testing Complete | milestone | 0d | 2007-06-01 | 2007-06-01 | 96 | 21d |  |  |
| 98 | 6.7 | Package Implementation Complete | milestone | 0d | 2007-06-01 | 2007-06-01 | 96 | 0d |  |  |
| 99 | 6.8 | **Finalize Integration Phase** |  | 4d | 2007-06-01 | 2007-06-07 |  | 0d |  | 56h |
| 100 | GRBAPI.PINT.GRSEA.010 | Develop Requirements Traceability Matrix |  | 1d | 2007-06-01 | 2007-06-04 | 98 | 0d | Human Resources; Information Systems | 16h |
| 101 | GRBAPI.PINT.GRSEA.020 | Baseline Project/Deliverables |  | 1d | 2007-06-04 | 2007-06-05 | 100 | 0d | Human Resources; Information Systems | 16h |
| 102 | GRBAPI.PINT.GRSEA.030 | Develop Schedule for Next Stage |  | 1d | 2007-06-05 | 2007-06-06 | 101 | 0d | Human Resources; Information Systems | 16h |
| 103 | GRBAPI.PINT.GRSEA.040 | Review Project Status with Project Board |  | 1d | 2007-06-06 | 2007-06-07 | 102 | 0d | Human Resources | 8h |
| 104 | 6.8.5 | Finalize Integration Phase Complete | milestone | 0d | 2007-06-07 | 2007-06-07 | 103 | 0d |  |  |
| 105 | 7 | **Deploy** |  | 17d? | 2007-06-07 | 2007-07-02 |  | 0d |  | 176h |
| 106 | 7.1 | **Education Development** |  | 4d | 2007-06-07 | 2007-06-13 |  | 0d |  | 56h |
| 107 | 7.1.1 | Set Up Training Environment |  | 1d | 2007-06-07 | 2007-06-08 | 104 | 0d | Information Systems | 8h |
| 108 | 7.1.2 | Create Application User Guide |  | 1d | 2007-06-08 | 2007-06-11 | 107 | 0d | Information Systems; Human Resources | 16h |
| 109 | 7.1.3 | Create Administrators Guide |  | 1d | 2007-06-11 | 2007-06-12 | 108 | 0d | Information Systems; Human Resources | 16h |
| 110 | 7.1.4 | Develop Training Materials |  | 1d | 2007-06-12 | 2007-06-13 | 109 | 0d | Information Systems; Human Resources | 16h |
| 111 | 7.1.5 | Education Development Complete | milestone | 0d | 2007-06-13 | 2007-06-13 | 110 | 0d |  |  |

| ID | WBS | Task | Type | Duration | Start | Finish | Predecessors | Total slack | Resources | Work |
| --- | --- | --- | --- | --- | --- | --- | --- | --- | --- | --- |
| 112 | 7.2 | **Deployment Preparation** |  | 6d | 2007-06-13 | 2007-06-21 |  | 0d |  | 48h |
| 113 | 7.2.1 | Develop Background Scheduling Processes |  | 1d | 2007-06-13 | 2007-06-14 | 111 | 0d | Information Systems | 8h |
| 114 | 7.2.2 | Create Production Test Scripts |  | 1d | 2007-06-14 | 2007-06-15 | 113 | 0d | Information Systems | 8h |
| 115 | 7.2.3 | Review and Compile Technical Implementation Plan |  | 1d | 2007-06-15 | 2007-06-18 | 113, 114 | 0d | Information Systems | 8h |
| 116 | 7.2.4 | Establish Technical Environment |  | 1d | 2007-06-18 | 2007-06-19 | 115 | 0d | Information Systems | 8h |
| 117 | 7.2.5 | Conduct Deployment Briefings |  | 1d | 2007-06-19 | 2007-06-20 | 116 | 0d | Information Systems | 8h |
| 118 | 7.2.6 | Conduct Training |  | 1d | 2007-06-20 | 2007-06-21 | 117 | 7d | Human Resources | 8h |
| 119 | 7.2.7 | Complete Process Review |  | 1d | 2007-06-20 | 2007-06-21 | 117 | 0d |  |  |
| 120 | 7.2.8 | Deployment Preparation Complete | milestone | 0d | 2007-06-21 | 2007-06-21 | 119 | 0d |  |  |
| 121 | 7.3 | **Installation and Handover** |  | 5d | 2007-06-21 | 2007-06-28 |  | 0d |  | 40h |
| 122 | 7.3.1 | Install Application Software |  | 1d | 2007-06-21 | 2007-06-22 | 120 | 0d | Information Systems | 8h |
| 123 | 7.3.2 | Convert Static and Acquire New Data |  | 1d | 2007-06-22 | 2007-06-25 | 122 | 0d | Information Systems | 8h |
| 124 | 7.3.3 | Convert Dynamic Data |  | 1d | 2007-06-22 | 2007-06-25 | 122 | 0d | Information Systems | 8h |
| 125 | 7.3.4 | Perform Production Tests |  | 1d | 2007-06-25 | 2007-06-26 | 123, 124 | 0d | Information Systems | 8h |
| 126 | 7.3.5 | Cut Over to New Application |  | 1d | 2007-06-26 | 2007-06-27 | 125 | 0d | Information Systems | 8h |
| 127 | 7.3.6 | Create Maintenance Guide |  | 1d | 2007-06-27 | 2007-06-28 | 126 | 0d |  |  |
| 128 | 7.3.7 | Installation and Handover Complete | milestone | 0d | 2007-06-28 | 2007-06-28 | 127 | 0d |  |  |
| 129 | 7.4 | **Finalize Deployment Phase** |  | 2d? | 2007-06-28 | 2007-07-02 |  | 0d |  | 32h |
| 130 | 7.4.1 | Perform Lessons Learned Meeting |  | 1d? | 2007-06-28 | 2007-06-29 | 128 | 0d | Information Systems; Human Resources | 16h |
| 131 | 7.4.2 | Close Project File |  | 1d? | 2007-06-29 | 2007-07-02 | 130 | 0d | Information Systems; Human Resources | 16h |
| 132 | 7.4.3 | Finalize Deployment Phase Complete | milestone | 0d | 2007-07-02 | 2007-07-02 | 131 | 0d |  |  |
| 133 | 7.5 | Deployment Complete | milestone | 0d | 2007-07-02 | 2007-07-02 | 131 | 0d |  |  |
| 134 | 8 | HRIS Implementation Complete | milestone | 0d | 2007-07-02 | 2007-07-02 | 133 | 0d |  |  |
