# Installation Microsoft Office SharePoint Server 2007

Schedule from MS Project, 2008-02-28 to 2008-04-15.

## Calendars

- Standard: Mon-Fri 08:00-12:00, 13:00-17:00; Sat-Sun off.

## Schedule

| ID | WBS | Task | Type | Duration | Start | Finish | Predecessors | Total slack | Free slack |
| --- | --- | --- | --- | --- | --- | --- | --- | --- | --- |
| 1 | 1 | Template start and notes | milestone | 0d | 2008-02-28 | 2008-02-28 |  | 0d |  |
| 2 | 2 | **Evaluate** |  | 6d? | 2008-02-28 | 2008-03-06 |  | 0d |  |
| 3 | 2.1 | Review platform capabilities and potential uses |  | 1d? | 2008-02-28 | 2008-02-28 | 1 | 0d |  |
| 4 | 2.2 | Determine end user requirements and proposed uses |  | 1d? | 2008-02-29 | 2008-02-29 | 3 | 0d |  |
| 5 | 2.3 | Determine planned uses of the Windows Workflow Foundation |  | 1d? | 2008-03-03 | 2008-03-03 | 4 | 0d |  |
| 6 | 2.4 | Determine potential IT enhancement areas |  | 1d? | 2008-03-04 | 2008-03-04 | 5 | 0d |  |
| 7 | 2.5 | Determine if single server or farm installation is needed |  | 1d? | 2008-03-05 | 2008-03-05 | 6 | 0d |  |
| 8 | 2.6 | Determine hardware, software, network & application administration high-level requirements |  | 1d? | 2008-03-06 | 2008-03-06 | 7 | 0d |  |
| 9 | 3 | Evaluation phase complete | milestone | 0d | 2008-03-06 | 2008-03-06 | 8 | 0d |  |
| 10 | 4 | **Plan** |  | 5d? | 2008-03-07 | 2008-03-13 |  | 0d |  |
| 11 | 4.1 | Plan browser support |  | 1d? | 2008-03-07 | 2008-03-07 | 9 | 0d |  |
| 12 | 4.2 | Finalize hardware, network, and software requirements |  | 1d? | 2008-03-10 | 2008-03-10 | 11 | 0d |  |
| 13 | 4.3 | Plan administrative roles |  | 1d? | 2008-03-11 | 2008-03-11 | 12 | 0d |  |
| 14 | 4.4 | Confirm licensing and media |  | 1d? | 2008-03-11 | 2008-03-11 | 12 | 25d |  |
| 15 | 4.5 | Order and install hardware and network components |  | 1d? | 2008-03-11 | 2008-03-11 | 12 | 2d |  |
| 16 | 4.6 | Train administrators and IT professionals in the platform and their roles |  | 1d? | 2008-03-12 | 2008-03-12 | 13 | 0d |  |
| 17 | 4.7 | Develop topography and initial rollout plan |  | 1d? | 2008-03-13 | 2008-03-13 | 16 | 0d |  |
| 18 | 5 | Planning phase complete | milestone | 0d | 2008-03-13 | 2008-03-13 | 15, 17 | 0d |  |
| 19 | 6 | **Deploy** |  | 20d? | 2008-03-14 | 2008-04-10 |  | 0d |  |
| 20 | 6.1 | **User readiness** |  | 2d? | 2008-03-14 | 2008-03-17 |  | 16d |  |
| 21 | 6.1.1 | Communicate timing, training, and support plan for the installation |  | 1d? | 2008-03-14 | 2008-03-14 | 18 | 16d | 0d |
| 22 | 6.1.2 | Train IT community, as appropriate, on the platform |  | 1d? | 2008-03-17 | 2008-03-17 | 21 | 16d |  |
| 23 | 6.2 | **Install prerequisites** |  | 5d? | 2008-03-14 | 2008-03-20 |  | 0d |  |
| 24 | 6.2.1 | Install and configure IIS |  | 1d? | 2008-03-14 | 2008-03-14 | 18 | 0d |  |
| 25 | 6.2.2 | Install and enable ASP.NET 2.0 |  | 1d? | 2008-03-17 | 2008-03-17 | 24 | 0d |  |
| 26 | 6.2.3 | Install the Microsoft .NET Framework version 3.0 |  | 1d? | 2008-03-18 | 2008-03-18 | 25 | 0d |  |
| 27 | 6.2.4 | Install and configure SQL Server 2005 |  | 1d? | 2008-03-19 | 2008-03-19 | 26 | 0d |  |
| 28 | 6.2.5 | Patch software as necessary (IIS, SQL Server to SP2, etc.) |  | 1d? | 2008-03-20 | 2008-03-20 | 27 | 0d |  |

Notes:
- 1: This template provides guidance regarding the installation of Microsoft Office SharePoint Server 2007. Microsoft Office Sharepoint Server 2007 (MOSS) is built on the WSS 3.0 platform. The template does not cover upgrading from previous releases of Office SharePoint Server 2007 or how to upgrade from Microsoft SharePoint Portal Server 2003. It does not attempt to describe all steps within the installation process but rather the overall plan with pointers to supplemental documentation that provides details at various steps within the project. A detailed expanation of Microsoft Office SharePoint Server 2007 deployment is available online at: http://technet.microsoft.com/Office / Because this is a template, all durations are left at a default level of 1 day, and limited resources have been included. / With this version of MOSS, there are new features that need to be considered when planning the installation: / ·Iimproved administration model to centralize configuration and management tasks and manage administrative roles. / ·New and improved compliance features and capabilities / ·New and improved operational tools and capabilities. / ·Improved support for network configuration. / ·Improved extensibility of the object model.
- 3: There are many benefits, including workflow solutions provided by Microsoft Office SharePoint Server 2007. The features include support areas of portal, search, content management, business forms and integration, and business intelligence. This system should be considered a platform for building many solutions, all of which will require planning of their own. Without a logical approach to using the system, the end user experience can be chaotic. / Before launching this project, the organizations needs to have a thorough understanding of capabilities and probably uses of the platform. / Download the "Microsoft Office SharePoint Server 2007 Evaluation Guide" as an aid to gaining this knowledge. / http://go.microsoft.com/fwlink/?LinkId=83060&clcid=0x409
- 4: Once the existing environment and the minimum requirements for installation are known, prepare an impact analysis that identifies hardware and software upgrade requirements, end user capabilities and training needs, and administrator capability and training needs. / The eventual output of this step should be the requirements that will help the organization determine the scale and general timing of the proposed solution(s) to be built on the platform.
- 5: The features available with Microsoft Office SharePoint 2007 allow for very robust and complex workflow dynamics. The potential uses are numerable so awareness of this capability needs to be well understood to aid in properly sizing the platform and planning for eventual solutions that will use it.
- 6: Different roles in an organization will use the solution differently. IT will need to be the leaders regarding direction for the entire organization as well as the architects of the solution for their own use. IT professionals will need to learn new skills to direct the development of the solutions.
- 7: The primary difference between a single server and a server farm topology is that you can use one or more computers to host the following server roles: / ·pplication server / ·Front-end Web server / ·Database server / Only the single server install is included in this template. Although the steps are similar, a multi-server install is more complex and will vary with the number of servers and the other systems involved. Detailed support is available through Technet online and many other publicsations. Many experienced Microsoft partners are also available to help with complex installations that require more integration with other systems.
- 8: Microsoft Office SharePoint 2007 can be deployed for a small set of users or an entire organization. Once end user requirements and organizational goals are understoon, the technical requirements can be developed. / Capacity planning and future use determinatin is critical. Microsoft Office SharePoint 2007 can be installed in a single server environment but it will be easier to scale the system for future growth if it is initially set up in a server farm environment. / This template will cover only the single server setup.
- 11: Microsoft Office SharePoint Server 2007 supports several Web browsers that are commonly used. However, because of the use of Active X controls, there are certain browsers that might cause some Office SharePoint Server 2007 functionality to be downgraded, limited, or available only through alternative steps. In some cases, functionality might be unavailable for noncritical administrative tasks. evel 2 Web browsers provide basic functionality, so that users can both read and write in SharePoint sites and perform site administration. / Level 1 browsers (at the time this template was created) include: / ·Microsoft Internet Explorer 6.x (32-bit) / ·Windows Internet Explorer 7.x (32-bit) / Examples of Level 2 browsers are Firefox 1.5, Netscape Navigator 7.2 & 8.1, Mozilla 1.7, and Safari 2.0. / If not included in the list above, the browser may not be supported.
- 13: Microsoft Office SharePoint 2007 was build with three tiers of administration. Administration can be performed by different functional roles: / ·1- central administration of farm, / ·2- manage shared services such as search, usage, and indexing, / ·3- manage site level such as lists, site users, and hierarchy
- 14: Installation media should be secured with the appropriate licensing as required for the user community.
- 16: Microsoft Office SharePoint 2007 is typically rolled out gradually to the user base. It is recommended that IT be among the first set of users so they can gain the necessary experience to guide the rest of the organization.
- 17: Microsoft Office SharePoint 2007 provides the highest return on investment and lowest TCO when its structure and planned use is well orchestrated. / If installed only for collaboration and search purposes without this topography, it can become difficult to administer and has limited value. A strong topography and rollout plan will minimize these problems.
- 19: This template provides guidance regarding the installation of Microsoft Office SharePoint Server 2007. Microsoft Office Sharepoint Server 2007 (MOSS) is built on the WSS 3.0 platform. The template does not cover upgrading from previous releases of Microsoft Office SharePoint Server 2007 or how to upgrade from Microsoft SharePoint Portal Server 2003. It does not attempt to describe all steps within the installation process but rather the overall plan with pointers to supplemental documentation that provides details at various steps within the project. A detailed expanation of Microsoft Office SharePoint Server 2007 deployment is available online at http://technet.microsoft.com/Office
- 21: Communication of the plan prior to the installation will create awareness and will alleviate some of the normal concerns that arise with any change.
- 22: This template assumes a structured rollout of the platform with a strong IT organization to support it.
- 23: The TechNet site: http://technet.microsoft.com/Office has a complete set of detailed instructions that will help the installation team prepare for installationt. The following is offered as high-level guidance for a single server install only. / Before you install and configure Microsoft Office SharePoint Server 2007, you must install and configure the required prerequisite software. This includes installing and configuring Internet Information Services (IIS) so your computer acts as a Web server, installing the Microsoft .NET Framework version 3.0, and enabling ASP.NET 2.0.
- 24: Internet Information Services (IIS) is not installed or enabled by default in the Microsoft Windows Server 2003 operating system. To make your server a Web server, you must install and enable IIS, and you must ensure that IIS is running in IIS 6.0 worker process isolation mode.
- 25: ASP.NET 2.0 is required for proper functioning of Web content, the Central Administration Web Site, and many other features and functions of Microsoft Office SharePoint Server 2007. / To enable ASP .NET 2.0: / 1. Click Start, point to All Programs, point to Administrative Tools, and then click Internet Information Services (IIS) Manager. / 2. In the Internet Information Services tree, click the plus sign (+) next to the server name, and then click the Web Service Extensions folder. / 3. In the details pane, right-click ASP.NET v2.0.50727, and then click Allow. / For more details go to http://technet.microsoft.com/en-us/library/aa560277.aspx
- 26: Go to the Microsoft Download Center Web site, and on the Microsoft .NET Framework 3.0 Redistributable Package page, follow the instructions for downloading and installing the .NET Framework version 3.0. There are separate downloads for x86-based computers and x64-based computers. Be sure to download and install the appropriate version for your computer. The .NET Framework version 3.0 download contains the Windows Workflow Foundation technology, which is required by workflow features.

| ID | WBS | Task | Type | Duration | Start | Finish | Predecessors | Total slack |
| --- | --- | --- | --- | --- | --- | --- | --- | --- |
| 29 | 6.3 | **Install and configure SharePoint 2007** |  | 6d? | 2008-03-21 | 2008-03-28 |  | 0d |
| 30 | 6.3.1 | Run setup choosing appropriate method |  | 1d? | 2008-03-21 | 2008-03-21 | 28 | 0d |
| 31 | 6.3.2 | Run the SharePoint Products and Technologies Configuration Wizard |  | 1d? | 2008-03-24 | 2008-03-24 | 30 | 0d |
| 32 | 6.3.3 | Add the SharePoint site to the list of trusted sites |  | 1d? | 2008-03-25 | 2008-03-25 | 31 | 0d |
| 33 | 6.3.4 | Configure proxy server settings to bypass the proxy server for local addresses |  | 1d? | 2008-03-26 | 2008-03-26 | 32 | 0d |
| 34 | 6.3.5 | Patch WSS 3.0 to latest service pack |  | 1d? | 2008-03-27 | 2008-03-27 | 33 | 0d |
| 35 | 6.3.6 | Patch MOSS to latest service pack |  | 1d? | 2008-03-28 | 2008-03-28 | 34 | 0d |
| 36 | 6.4 | **Perform administrative tasks** |  | 7d? | 2008-03-31 | 2008-04-08 |  | 0d |
| 37 | 6.4.1 | Configure incoming/outgoing email settings |  | 1d? | 2008-03-31 | 2008-03-31 | 35 | 0d |
| 38 | 6.4.2 | Configure SharePoint sites |  | 1d? | 2008-04-01 | 2008-04-01 | 37 | 0d |
| 39 | 6.4.3 | Configure workflow settings |  | 1d? | 2008-04-02 | 2008-04-02 | 38 | 0d |
| 40 | 6.4.4 | Configure diagnostic logging settings |  | 1d? | 2008-04-03 | 2008-04-03 | 39 | 0d |
| 41 | 6.4.5 | Configure anti-virus protection |  | 1d? | 2008-04-04 | 2008-04-04 | 40 | 0d |
| 42 | 6.4.6 | Configure search |  | 1d? | 2008-04-07 | 2008-04-07 | 41 | 0d |
| 43 | 6.4.7 | Configure Microsoft Office Excel services |  | 1d? | 2008-04-08 | 2008-04-08 | 42 | 0d |
| 44 | 6.5 | Test the installation and prepare for operations |  | 1d? | 2008-04-09 | 2008-04-09 | 43, 22 | 0d |
| 45 | 6.6 | Communicate final installation information |  | 1d? | 2008-04-10 | 2008-04-10 | 44 | 0d |
| 46 | 7 | Installation phase complete | milestone | 0d | 2008-04-10 | 2008-04-10 | 45 | 0d |
| 47 | 8 | **Operate** |  | 3d? | 2008-04-11 | 2008-04-15 |  | 0d |
| 48 | 8.1 | Finalize backup, recovery, & disaster recovery procedures |  | 1d? | 2008-04-11 | 2008-04-11 | 46 | 2d |
| 49 | 8.2 | Establish processes for monitoring the system |  | 1d? | 2008-04-11 | 2008-04-11 | 46 | 0d |
| 50 | 8.3 | Establish processes to perform regular maintenance and backup |  | 1d? | 2008-04-14 | 2008-04-14 | 49 | 0d |
| 51 | 8.4 | Transition to operational mode and close project |  | 1d? | 2008-04-15 | 2008-04-15 | 50 | 0d |
| 52 | 9 | Project complete | milestone | 0d | 2008-04-15 | 2008-04-15 | 51 | 0d |

Notes:
- 29: You can install Microsoft Office SharePoint Server 2007 on a single computer or in a server farm. There are two options: / ·By selecting Basic. / ·By selecting Advanced (recommended), and then selecting the appropriate option - Complete (Recommended), Web Front End, or Stand-alone in Microsoft Office SharePoint Server 2007 Setup. / Advanced > Complete provides the most flexibility and can be done in a stand-alone or server farm environment. / Note / If you uninstall Microsoft Office SharePoint Server 2007 and then later install Microsoft Office SharePoint Server 2007 on the same computer, the Setup program could fail when creating the configuration database causing the entire installation process to fail. You can prevent this failure by either deleting all the existing Microsoft Office SharePoint Server 2007 databases on the computer or by creating a new configuration database. You can create a new configuration database by running the following command: / psconfig -cmd configdb -create -database <uniquename> / The TechNet site: http://technet.microsoft.com/Office has a complete set of detailed instructions. This note includes basic information only.
- 30: You can install Microsoft Office SharePoint Server 2007 on a single computer or in a server farm. There are two options: / ·By selecting Basic. / ·By selecting Advanced (recommended), and then selecting the appropriate option - Complete (Recommended), Web Front End, or Stand-alone in Microsoft Office SharePoint Server 2007 Setup. / Advanced > Complete provides the most flexibility and can be done in a stand-alone or server farm environment. / Setup automatically verifies the product key, places a green check mark next to the text box, and enables the Continue button after it validates the key. If the key is not valid, Setup places a red circle next to the text box and displays a message that the key is incorrect. / See http://technet.microsoft.com/Office for more details.
- 31: If you are prompted for your user name and password, you might need to add the SharePoint site to the list of trusted sites and configure user authentication settings in Internet Explorer. Instructions for configuring these settings are provided in the following procedure. / If you see a proxy server error message, you might need to configure your proxy server settings so that local addresses bypass the proxy server. Instructions for configuring proxy server settings are provided later in this section.
- 33: If you are not using proxy servers, ignore this step.
- 36: Once the installation is complete, there are many administrative tasks to be completed to prepare the platform for use. Review the possibilities prior to the installation so that you are ready to configure each of the items in this set of tasks.
- 45: Details of how and where to access the platform need to be provided to the initial set of users so they can test the platform and begin adding customization as planned.
