# Software Localization

Schedule from MS Project, 2004-01-01 to 2004-07-22.

## Calendars

- Standard: Mon-Fri 08:00-12:00, 13:00-17:00; Sat-Sun off.

## Resources

| Resource |
| --- |
| Management |
| Project manager |
| Analyst |
| International program manager |
| Translator |
| Localizer |
| Technical reviewer |
| Localization engineer |

## Schedule

| ID | WBS | Task | Type | Duration | Start | Finish | Predecessors | Total slack | Resources | Work |
| --- | --- | --- | --- | --- | --- | --- | --- | --- | --- | --- |
| 1 | 1 | **Product Localization Template** |  | 146d | 2004-01-01 | 2004-07-22 |  | 0d |  | 3472h |
| 2 | 1.1 | **Scope** |  | 25d | 2004-01-01 | 2004-02-04 |  | 0d |  | 240h |
| 3 | 1.1.1 | Review business case |  | 2d | 2004-01-01 | 2004-01-02 |  | 0d | Project manager; Management | 32h |
| 4 | 1.1.2 | Estimate project undertaking (for example, volumes, details/extent of localization) |  | 1w | 2004-01-05 | 2004-01-09 | 3 | 0d | Project manager | 40h |
| 5 | 1.1.3 | Prepare localization specification (feasibility, for markets) |  | 2d | 2004-01-12 | 2004-01-13 | 4 | 0d | Project manager | 16h |
| 6 | 1.1.4 | Estimate costs |  | 3d | 2004-01-14 | 2004-01-16 | 5 | 0d | Project manager | 24h |
| 7 | 1.1.5 | Identify risks |  | 2d | 2004-01-19 | 2004-01-20 | 6 | 0d | Project manager | 16h |
| 8 | 1.1.6 | Secure project sponsorship |  | 1d | 2004-01-21 | 2004-01-21 | 7 | 0d | Management | 8h |
| 9 | 1.1.7 | Define preliminary resources |  | 1w | 2004-01-22 | 2004-01-28 | 8 | 0d | Project manager | 40h |
| 10 | 1.1.8 | Define project communications matrix/methods |  | 3d | 2004-01-22 | 2004-01-26 | 8 | 7d | Project manager | 24h |
| 11 | 1.1.9 | Secure core resources |  | 1w | 2004-01-29 | 2004-02-04 | 9 | 0d | Project manager | 40h |
| 12 | 1.1.10 | Scope complete | milestone | 0d | 2004-02-04 | 2004-02-04 | 11, 10 | 0d |  |  |
| 13 | 1.2 | **Analysis/Planning** |  | 38d | 2004-02-05 | 2004-03-29 |  | 0d |  | 1128h |
| 14 | 1.2.1 | Identify localization resources (internal and outsourced) |  | 5d | 2004-02-05 | 2004-02-11 | 12 | 0d | Analyst | 40h |
| 15 | 1.2.2 | **Identify Components to be Localized** |  | 5d | 2004-02-12 | 2004-02-18 |  | 0d | Analyst | 440h |
| 16 | 1.2.2.1 | **Software Components** |  | 5d | 2004-02-12 | 2004-02-18 |  | 0d |  | 80h |
| 17 | 1.2.2.1.1 | Setup |  | 1w | 2004-02-12 | 2004-02-18 | 14 | 0d | Analyst | 40h |
| 18 | 1.2.2.1.2 | User interface |  | 1w | 2004-02-12 | 2004-02-18 | 14 | 0d | Analyst | 40h |
| 19 | 1.2.2.2 | **User Assistance Components** |  | 5d | 2004-02-12 | 2004-02-18 |  | 0d |  | 80h |
| 20 | 1.2.2.2.1 | Online help, documentation, frequently asked questions (FAQs) |  | 1w | 2004-02-12 | 2004-02-18 | 14 | 0d | Analyst | 40h |
| 21 | 1.2.2.2.2 | User guide |  | 1w | 2004-02-12 | 2004-02-18 | 14 | 0d | Analyst | 40h |
| 22 | 1.2.2.3 | **Marketing Components** |  | 5d | 2004-02-12 | 2004-02-18 |  | 0d |  | 120h |
| 23 | 1.2.2.3.1 | Packaging |  | 1w | 2004-02-12 | 2004-02-18 | 14 | 0d | Analyst | 40h |
| 24 | 1.2.2.3.2 | Brochures |  | 1w | 2004-02-12 | 2004-02-18 | 14 | 0d | Analyst | 40h |
| 25 | 1.2.2.3.3 | Web content |  | 1w | 2004-02-12 | 2004-02-18 | 14 | 0d | Analyst | 40h |

Notes:
- 15: A variety of components need to be identified for your specific product's localization. We have provided a sampling to help you identify them. Keep in mind that each of these items can be further expanded to better reflect the scope of your project.

| ID | WBS | Task | Type | Duration | Start | Finish | Predecessors | Total slack | Free slack | Resources | Work |
| --- | --- | --- | --- | --- | --- | --- | --- | --- | --- | --- | --- |
| 26 | 1.2.2.4 | **Ancillary Components** |  | 5d | 2004-02-12 | 2004-02-18 |  | 0d |  |  | 120h |
| 27 | 1.2.2.4.1 | Macros |  | 1w | 2004-02-12 | 2004-02-18 | 14 | 0d |  | Analyst | 40h |
| 28 | 1.2.2.4.2 | Add-ins |  | 1w | 2004-02-12 | 2004-02-18 | 14 | 0d |  | Analyst | 40h |
| 29 | 1.2.2.4.3 | Templates |  | 1w | 2004-02-12 | 2004-02-18 | 14 | 0d |  | Analyst | 40h |
| 30 | 1.2.2.4.4 | Identify components to be localized complete | milestone | 0d | 2004-02-18 | 2004-02-18 | 29, 28, 27, 25, 23, 21, 20, 17, 18, 24 | 0d |  |  |  |
| 31 | 1.2.3 | Ensure file localizability |  | 1w | 2004-02-19 | 2004-02-25 | 30 | 0d |  | Project manager; Analyst; Localization engineer | 120h |
| 32 | 1.2.4 | Define localization processes |  | 2w | 2004-02-26 | 2004-03-10 | 31 | 0d |  | Project manager; Analyst; Localization engineer | 240h |
| 33 | 1.2.5 | Identify tools |  | 5d | 2004-02-26 | 2004-03-03 | 31 | 3d | 0d | Localization engineer; Analyst | 80h |
| 34 | 1.2.6 | Test tools |  | 2d | 2004-03-04 | 2004-03-05 | 33 | 3d |  | Localization engineer | 16h |
| 35 | 1.2.7 | Document localization process |  | 2d | 2004-03-11 | 2004-03-12 | 34, 32 | 0d |  | Localization engineer; Analyst | 32h |
| 36 | 1.2.8 | Prepare risk management plan |  | 3d | 2004-03-15 | 2004-03-17 | 32, 35 | 0d |  | International program manager; Project manager | 48h |
| 37 | 1.2.9 | Define communication procedures |  | 2d | 2004-03-18 | 2004-03-19 | 36 | 0.5d |  | Project manager; International program manager | 32h |
| 38 | 1.2.10 | Identify time constraints |  | 1d | 2004-03-18 | 2004-03-18 | 36 | 0d |  | Project manager; International program manager | 16h |
| 39 | 1.2.11 | Identify key milestones |  | 4h | 2004-03-19 | 2004-03-19 | 38 | 0d |  | Project manager; Analyst | 8h |
| 40 | 1.2.12 | Develop delivery timeline |  | 1d | 2004-03-19 | 2004-03-22 | 39 | 0d |  | Project manager | 8h |
| 41 | 1.2.13 | Obtain approvals to proceed (for example, concept, timeline, budget) |  | 4h | 2004-03-22 | 2004-03-22 | 40, 37 | 0d |  | Management; Project manager | 8h |
| 42 | 1.2.14 | Secure required resources |  | 1w | 2004-03-23 | 2004-03-29 | 41 | 0d |  | Project manager | 40h |
| 43 | 1.2.15 | Analysis complete | milestone | 0d | 2004-03-29 | 2004-03-29 | 42 | 0d |  |  |  |
| 44 | 1.3 | **Production** |  | 25d | 2004-03-30 | 2004-05-03 |  | 0d |  |  | 968h |
| 45 | 1.3.1 | **Software Components** |  | 11d | 2004-03-30 | 2004-04-13 |  | 3d |  |  | 128h |
| 46 | 1.3.1.1 | **Localization Component - Setup** |  | 11d | 2004-03-30 | 2004-04-13 |  | 14d |  |  | 64h |
| 47 | 1.3.1.1.1 | Review identified component functionality |  | 1d | 2004-03-30 | 2004-03-30 | 43 | 14d | 0d | Localizer | 8h |
| 48 | 1.3.1.1.2 | Localize identified component |  | 1w | 2004-03-31 | 2004-04-06 | 47 | 14d | 0d | Localizer | 40h |
| 49 | 1.3.1.1.3 | Refine component based on quality assurance (QA) feedback |  | 2d | 2004-04-09 | 2004-04-12 | 102 | 14d | 0d | Localizer | 16h |
| 50 | 1.3.1.1.4 | Localization component setup complete | milestone | 0d | 2004-04-13 | 2004-04-13 | 103 | 21d | 0d |  |  |

Notes:
- 44: Depending on your process, development and quality assurance may be iterative. In this template they are listed once, but these tasks can be copied and inserted as necessary to better reflect your process.

| ID | WBS | Task | Type | Duration | Start | Finish | Predecessors | Total slack | Free slack | Resources | Work |
| --- | --- | --- | --- | --- | --- | --- | --- | --- | --- | --- | --- |
| 51 | 1.3.1.2 | **Localization Component - User Interface** |  | 11d | 2004-03-30 | 2004-04-13 |  | 3d |  |  | 64h |
| 52 | 1.3.1.2.1 | Review identified component functionality |  | 1d | 2004-03-30 | 2004-03-30 | 43 | 3d | 0d | Localizer | 8h |
| 53 | 1.3.1.2.2 | Localize identified component |  | 1w | 2004-03-31 | 2004-04-06 | 52 | 3d | 0d | Localizer | 40h |
| 54 | 1.3.1.2.3 | Refine component based on QA feedback |  | 2d | 2004-04-09 | 2004-04-12 | 105 | 3d | 0d | Localizer | 16h |
| 55 | 1.3.1.2.4 | Localization component - user interface complete | milestone | 0d | 2004-04-13 | 2004-04-13 | 106 | 3d | 0d |  |  |
| 56 | 1.3.1.3 | Software components complete | milestone | 0d | 2004-04-13 | 2004-04-13 | 55 | 3d | 0d |  |  |
| 57 | 1.3.2 | **User Assistance Components** |  | 11d | 2004-04-14 | 2004-04-28 |  | 3d |  |  | 128h |
| 58 | 1.3.2.1 | **Localization Component - Online Help, Documentation, FAQs** |  | 11d | 2004-04-14 | 2004-04-28 |  | 3d |  |  | 64h |
| 59 | 1.3.2.1.1 | Review identified component functionality |  | 1d | 2004-04-14 | 2004-04-14 | 56 | 3d | 0d | Localizer | 8h |
| 60 | 1.3.2.1.2 | Localize identified component |  | 1w | 2004-04-15 | 2004-04-21 | 59 | 3d | 0d | Localizer | 40h |
| 61 | 1.3.2.1.3 | Refine component based on QA feedback |  | 2d | 2004-04-26 | 2004-04-27 | 108 | 3d | 0d | Localizer | 16h |
| 62 | 1.3.2.1.4 | Localization component - online help, documentation, FAQs complete | milestone | 0d | 2004-04-28 | 2004-04-28 | 109 | 10d | 0d |  |  |
| 63 | 1.3.2.2 | **Localization Component - User Guide** |  | 11d | 2004-04-14 | 2004-04-28 |  | 3d |  |  | 64h |
| 64 | 1.3.2.2.1 | Review identified component functionality |  | 1d | 2004-04-14 | 2004-04-14 | 56 | 3d | 0d | Localizer | 8h |
| 65 | 1.3.2.2.2 | Localize identified component |  | 1w | 2004-04-15 | 2004-04-21 | 64 | 3d | 0d | Localizer | 40h |
| 66 | 1.3.2.2.3 | Refine component based on QA feedback |  | 2d | 2004-04-26 | 2004-04-27 | 111 | 3d | 0d | Localizer | 16h |
| 67 | 1.3.2.2.4 | Localization component - user guide | milestone | 0d | 2004-04-28 | 2004-04-28 | 112 | 10d | 0d |  |  |
| 68 | 1.3.2.3 | User assistance components complete | milestone | 0d | 2004-04-28 | 2004-04-28 | 67 | 61d |  |  |  |
| 69 | 1.3.3 | **Marketing Components** |  | 22d | 2004-03-30 | 2004-04-28 |  | 3d |  |  | 256h |
| 70 | 1.3.3.1 | **Localization Component - Marketing Materials** |  | 11d | 2004-03-30 | 2004-04-13 |  | 3d |  |  | 128h |
| 71 | 1.3.3.1.1 | Review identified component functionality |  | 1d | 2004-03-30 | 2004-03-30 | 43 | 3d | 0d | Localizer; Translator | 16h |
| 72 | 1.3.3.1.2 | Localize identified component |  | 1w | 2004-03-31 | 2004-04-06 | 71 | 3d | 0d | Localizer; Translator | 80h |
| 73 | 1.3.3.1.3 | Refine component based on QA feedback |  | 2d | 2004-04-09 | 2004-04-12 | 114 | 3d | 0d | Localizer; Translator | 32h |
| 74 | 1.3.3.1.4 | Localization component marketing materials complete | milestone | 0d | 2004-04-13 | 2004-04-13 | 73, 115 | 3d | 0d |  |  |

| ID | WBS | Task | Type | Duration | Start | Finish | Predecessors | Total slack | Free slack | Resources | Work |
| --- | --- | --- | --- | --- | --- | --- | --- | --- | --- | --- | --- |
| 75 | 1.3.3.2 | **Localization Component - Web Content** |  | 11d | 2004-04-14 | 2004-04-28 |  | 3d |  |  | 128h |
| 76 | 1.3.3.2.1 | Review identified component functionality |  | 1d | 2004-04-14 | 2004-04-14 | 74 | 3d | 0d | Localizer; Translator | 16h |
| 77 | 1.3.3.2.2 | Localize identified component |  | 1w | 2004-04-15 | 2004-04-21 | 76 | 3d | 0d | Localizer; Translator | 80h |
| 78 | 1.3.3.2.3 | Refine component based on QA feedback |  | 2d | 2004-04-26 | 2004-04-27 | 117 | 3d | 0d | Localizer; Translator | 32h |
| 79 | 1.3.3.2.4 | Localization component - web content | milestone | 0d | 2004-04-28 | 2004-04-28 | 78, 118 | 10d | 0d |  |  |
| 80 | 1.3.3.3 | Marketing components complete | milestone | 0d | 2004-04-28 | 2004-04-28 | 79 | 61d |  |  |  |
| 81 | 1.3.4 | **Ancillary Components** |  | 25d | 2004-03-30 | 2004-05-03 |  | 0d |  |  | 456h |
| 82 | 1.3.4.1 | **Localization Component - Macros** |  | 11d | 2004-03-30 | 2004-04-13 |  | 0d |  |  | 128h |
| 83 | 1.3.4.1.1 | Review identified component functionality |  | 1d | 2004-03-30 | 2004-03-30 | 43 | 0d |  | Localizer; Translator | 16h |
| 84 | 1.3.4.1.2 | Localize identified component |  | 1w | 2004-03-31 | 2004-04-06 | 83 | 0d |  | Localizer; Translator | 80h |
| 85 | 1.3.4.1.3 | Refine component based on QA feedback |  | 2d | 2004-04-09 | 2004-04-12 | 120 | 0d |  | Localizer; Translator | 32h |
| 86 | 1.3.4.1.4 | Localization component - macros | milestone | 0d | 2004-04-13 | 2004-04-13 | 121 | 0d |  |  |  |
| 87 | 1.3.4.2 | **Localization Component - Add-Ins** |  | 11d | 2004-04-14 | 2004-04-28 |  | 0d |  |  | 128h |
| 88 | 1.3.4.2.1 | Review identified component functionality |  | 1d | 2004-04-14 | 2004-04-14 | 86 | 0d |  | Localizer; Translator | 16h |
| 89 | 1.3.4.2.2 | Localize identified component |  | 1w | 2004-04-15 | 2004-04-21 | 88 | 0d |  | Localizer; Translator | 80h |
| 90 | 1.3.4.2.3 | Refine component based on QA feedback |  | 2d | 2004-04-26 | 2004-04-27 | 123 | 0d |  | Localizer; Translator | 32h |
| 91 | 1.3.4.2.4 | Localization component - add-ins | milestone | 0d | 2004-04-28 | 2004-04-28 | 124 | 0d |  |  |  |
| 92 | 1.3.4.3 | **Localization Component - Templates** |  | 11d | 2004-03-30 | 2004-04-13 |  | 11d |  |  | 128h |
| 93 | 1.3.4.3.1 | Review identified component functionality |  | 1d | 2004-03-30 | 2004-03-30 | 43 | 11d | 0d | Localizer; Translator | 16h |
| 94 | 1.3.4.3.2 | Localize identified component |  | 1w | 2004-03-31 | 2004-04-06 | 93 | 11d | 0d | Localizer; Translator | 80h |
| 95 | 1.3.4.3.3 | Refine component based on QA feedback |  | 2d | 2004-04-09 | 2004-04-12 | 126 | 11d | 0d | Localizer; Translator | 32h |
| 96 | 1.3.4.3.4 | Localization component - templates | milestone | 0d | 2004-04-13 | 2004-04-13 | 127 | 11d | 0d |  |  |
| 97 | 1.3.4.4 | Ancillary components complete | milestone | 0d | 2004-04-28 | 2004-04-28 | 91 | 0d |  |  |  |
| 98 | 1.3.4.5 | Validate final released software (decisions on development cycle) |  | 3d | 2004-04-29 | 2004-05-03 | 97, 96 | 0d |  | Project manager; International program manager; Management | 72h |
| 99 | 1.3.5 | Development complete | milestone | 0d | 2004-05-03 | 2004-05-03 | 97, 96, 98 | 8d |  |  |  |

Notes:
- 98: This template assumes that code complete occurs before localization. If the code is not complete before localization in your project, you will need to evaluate how to incorporate changes from ongoing change cycles as code becomes complete.

| ID | WBS | Task | Duration | Start | Finish | Predecessors | Total slack | Free slack | Resources | Work |
| --- | --- | --- | --- | --- | --- | --- | --- | --- | --- | --- |
| 100 | 1.4 | **Quality Assurance** | 27d | 2004-04-07 | 2004-05-13 |  | 0d |  |  | 432h |
| 101 | 1.4.1 | **Localization Component - Setup** | 5d | 2004-04-07 | 2004-04-13 |  | 14d |  |  | 24h |
| 102 | 1.4.1.1 | Test component - setup | 2d | 2004-04-07 | 2004-04-08 | 48 | 14d | 0d | Technical reviewer | 16h |
| 103 | 1.4.1.2 | QA review cycle | 1d | 2004-04-13 | 2004-04-13 | 49 | 14d | 0d | Technical reviewer | 8h |
| 104 | 1.4.2 | **Localization Component - User Interface** | 5d | 2004-04-07 | 2004-04-13 |  | 3d |  |  | 24h |
| 105 | 1.4.2.1 | Test component - user interface | 2d | 2004-04-07 | 2004-04-08 | 53 | 3d | 0d | Technical reviewer | 16h |
| 106 | 1.4.2.2 | QA review cycle | 1d | 2004-04-13 | 2004-04-13 | 54 | 3d | 0d | Technical reviewer | 8h |
| 107 | 1.4.3 | **Localization Component - Online Help, Documentation, FAQs** | 5d | 2004-04-22 | 2004-04-28 |  | 3d |  |  | 24h |
| 108 | 1.4.3.1 | Test component - online help, documentation, FAQs | 2d | 2004-04-22 | 2004-04-23 | 60 | 3d | 0d | Technical reviewer | 16h |
| 109 | 1.4.3.2 | QA review cycle | 1d | 2004-04-28 | 2004-04-28 | 61 | 3d | 0d | Technical reviewer | 8h |
| 110 | 1.4.4 | **Localization Component - User Guide** | 5d | 2004-04-22 | 2004-04-28 |  | 3d |  |  | 24h |
| 111 | 1.4.4.1 | Test component - user guide | 2d | 2004-04-22 | 2004-04-23 | 65 | 3d | 0d | Technical reviewer | 16h |
| 112 | 1.4.4.2 | QA review cycle | 1d | 2004-04-28 | 2004-04-28 | 66 | 3d | 0d | Technical reviewer | 8h |
| 113 | 1.4.5 | **Localization Component - Marketing Materials** | 5d | 2004-04-07 | 2004-04-13 |  | 3d |  |  | 24h |
| 114 | 1.4.5.1 | Test component - marketing materials | 2d | 2004-04-07 | 2004-04-08 | 72 | 3d | 0d | Technical reviewer | 16h |
| 115 | 1.4.5.2 | QA review cycle | 1d | 2004-04-13 | 2004-04-13 | 73 | 3d | 0d | Technical reviewer | 8h |
| 116 | 1.4.6 | **Localization Component - Web Content** | 5d | 2004-04-22 | 2004-04-28 |  | 3d |  |  | 24h |
| 117 | 1.4.6.1 | Test component - web content | 2d | 2004-04-22 | 2004-04-23 | 77 | 3d | 0d | Technical reviewer | 16h |
| 118 | 1.4.6.2 | QA review cycle | 1d | 2004-04-28 | 2004-04-28 | 78 | 3d | 0d | Technical reviewer | 8h |
| 119 | 1.4.7 | **Localization Component - Macros** | 5d | 2004-04-07 | 2004-04-13 |  | 0d |  |  | 24h |
| 120 | 1.4.7.1 | Test component - macros | 2d | 2004-04-07 | 2004-04-08 | 84 | 0d |  | Technical reviewer | 16h |
| 121 | 1.4.7.2 | QA review cycle | 1d | 2004-04-13 | 2004-04-13 | 85 | 0d |  | Technical reviewer | 8h |
| 122 | 1.4.8 | **Localization Component - Add-Ins** | 5d | 2004-04-22 | 2004-04-28 |  | 0d |  |  | 24h |
| 123 | 1.4.8.1 | Test component - add-ins | 2d | 2004-04-22 | 2004-04-23 | 89 | 0d |  | Technical reviewer | 16h |
| 124 | 1.4.8.2 | QA review cycle | 1d | 2004-04-28 | 2004-04-28 | 90 | 0d |  | Technical reviewer | 8h |

| ID | WBS | Task | Type | Duration | Start | Finish | Predecessors | Total slack | Free slack | Resources | Work |
| --- | --- | --- | --- | --- | --- | --- | --- | --- | --- | --- | --- |
| 125 | 1.4.9 | **Localization Component - Templates** |  | 5d | 2004-04-07 | 2004-04-13 |  | 11d |  |  | 24h |
| 126 | 1.4.9.1 | Test component - templates |  | 2d | 2004-04-07 | 2004-04-08 | 94 | 11d | 0d | Technical reviewer | 16h |
| 127 | 1.4.9.2 | QA review cycle |  | 1d | 2004-04-13 | 2004-04-13 | 95 | 11d | 0d | Technical reviewer | 8h |
| 128 | 1.4.10 | **Integration Testing** |  | 7d | 2004-05-04 | 2004-05-12 |  | 0d |  |  | 56h |
| 129 | 1.4.10.1 | Full component test |  | 1w | 2004-05-04 | 2004-05-10 | 127, 124, 121, 118, 115, 112, 109, 106, 103, 98 | 0d |  | Technical reviewer | 40h |
| 130 | 1.4.10.2 | QA review cycle |  | 2d | 2004-05-11 | 2004-05-12 | 129 | 0d |  | Technical reviewer | 16h |
| 131 | 1.4.11 | **Sponsor Review** |  | 22d | 2004-04-14 | 2004-05-13 |  | 0d |  |  | 160h |
| 132 | 1.4.11.1 | Review component - setup |  | 1d | 2004-04-14 | 2004-04-14 | 50 | 21d |  | Management; International program manager | 16h |
| 133 | 1.4.11.2 | Review component - user interface |  | 1d | 2004-04-14 | 2004-04-14 | 55 | 21d |  | Management; International program manager | 16h |
| 134 | 1.4.11.3 | Review component - online help, documentation, FAQs |  | 1d | 2004-04-29 | 2004-04-29 | 62 | 10d |  | Management; International program manager | 16h |
| 135 | 1.4.11.4 | Review component - user guide |  | 1d | 2004-04-29 | 2004-04-29 | 67 | 10d |  | Management; International program manager | 16h |
| 136 | 1.4.11.5 | Review component - marketing materials |  | 1d | 2004-04-14 | 2004-04-14 | 74 | 21d |  | Management; International program manager | 16h |
| 137 | 1.4.11.6 | Review component - web content |  | 1d | 2004-04-29 | 2004-04-29 | 79 | 10d |  | Management; International program manager | 16h |
| 138 | 1.4.11.7 | Review component - macros |  | 1d | 2004-04-14 | 2004-04-14 | 86 | 21d |  | Management; International program manager | 16h |
| 139 | 1.4.11.8 | Review component - add-ins |  | 1d | 2004-04-29 | 2004-04-29 | 91 | 10d |  | Management; International program manager | 16h |
| 140 | 1.4.11.9 | Review component - templates |  | 1d | 2004-04-14 | 2004-04-14 | 96 | 21d |  | Management; International program manager | 16h |
| 141 | 1.4.11.10 | Review integrated product |  | 1d | 2004-05-13 | 2004-05-13 | 130 | 0d |  | Management; International program manager | 16h |
| 142 | 1.4.12 | Quality assurance complete | milestone | 0d | 2004-05-13 | 2004-05-13 | 132, 133, 134, 135, 136, 137, 138, 139, 140, 141 | 0d |  |  |  |
| 143 | 1.5 | **Beta Testing** |  | 33d | 2004-05-14 | 2004-06-29 |  | 0d |  |  | 568h |
| 144 | 1.5.1 | Disseminate completed product |  | 3d | 2004-05-14 | 2004-05-18 | 99, 142 | 0d |  | Management; International program manager | 48h |
| 145 | 1.5.2 | Obtain feedback |  | 4w | 2004-05-19 | 2004-06-15 | 144 | 0d |  | Management; International program manager | 320h |
| 146 | 1.5.3 | Modify |  | 1w | 2004-06-16 | 2004-06-22 | 145 | 0d |  | Management; International program manager; Localization engineer | 120h |
| 147 | 1.5.4 | Test |  | 1w | 2004-06-23 | 2004-06-29 | 146 | 0d |  | Management; International program manager | 80h |
| 148 | 1.5.5 | Complete | milestone | 0d | 2004-06-29 | 2004-06-29 | 147 | 0d |  |  |  |

| ID | WBS | Task | Type | Duration | Start | Finish | Predecessors | Total slack | Resources | Work |
| --- | --- | --- | --- | --- | --- | --- | --- | --- | --- | --- |
| 149 | 1.6 | **Post-Project Review** |  | 17d | 2004-06-30 | 2004-07-22 |  | 0d |  | 136h |
| 150 | 1.6.1 | Review project information |  | 1w | 2004-06-30 | 2004-07-06 | 148 | 0d | Project manager | 40h |
| 151 | 1.6.2 | Finalize cost analysis |  | 3d | 2004-07-07 | 2004-07-09 | 150 | 0d | Project manager | 24h |
| 152 | 1.6.3 | Analyze performance |  | 3d | 2004-07-12 | 2004-07-14 | 151 | 0d | Project manager | 24h |
| 153 | 1.6.4 | Archive files |  | 2d | 2004-07-15 | 2004-07-16 | 152 | 0d | Project manager | 16h |
| 154 | 1.6.5 | Document lessons learned |  | 2d | 2004-07-19 | 2004-07-20 | 153 | 0d | Project manager | 16h |
| 155 | 1.6.6 | Distribute to team members |  | 2d | 2004-07-21 | 2004-07-22 | 154 | 0d | Project manager | 16h |
| 156 | 1.6.7 | Post-project review complete | milestone | 0d | 2004-07-22 | 2004-07-22 | 155 | 0d |  |  |
